# online-storage-disaster-recovery-project-plan

Schedule from MS Project, 2009-08-17 to 2009-10-26.
TheProjectDiva.com

## Calendars

- Standard: Mon-Fri 08:00-12:00, 13:00-17:00; Sat-Sun off.

## Resources

| Resource |
| --- |
| PM |
| Developer |
| Sys Admin |
| Sponsor |
| Support Manager |
| Sysadmin |
| Beta team |
| Developer 2 |

## Schedule

| ID | WBS | Task | Type | Duration | Start | Finish | Predecessors | Total slack | Resources | Work |
| --- | --- | --- | --- | --- | --- | --- | --- | --- | --- | --- |
| 1 | 1 | Online storage and backup solution -- new product development project | milestone | 0d | 2009-08-17 | 2009-08-17 |  | 3d |  |  |
| 2 | 2 | **Project initiation** |  | 9d | 2009-08-17 | 2009-08-27 |  | 0d |  |  |
| 3 | 2.1 | Business case development |  | 3d | 2009-08-17 | 2009-08-19 |  | 0d |  |  |
| 4 | 2.2 | Project kickoff | milestone | 1d | 2009-08-27 | 2009-08-27 | 3FS+5d | 0d |  |  |
| 5 | 3 | **Project planning** |  | 13d | 2009-08-28 | 2009-09-15 | 2 | 0d |  | 212h |
| 6 | 3.1 | **Requirements definition** |  | 4.5d | 2009-08-28 | 2009-09-03 |  | 0d |  | 84h |
| 7 | 3.1.1 | Residential customer requirements |  | 0.5d | 2009-08-28 | 2009-08-28 |  | 0d | PM; Developer | 8h |
| 8 | 3.1.2 | Business customer requirements |  | 0.5d | 2009-08-28 | 2009-08-28 |  | 0d | PM; Developer | 8h |
| 9 | 3.1.3 | Internal provisioning requirements |  | 0.5d | 2009-08-31 | 2009-08-31 | 7FS+1d, 8FS+1d | 0d | PM; Developer; Sys Admin | 12h |
| 10 | 3.1.4 | **System management requirements** |  | 0.5d | 2009-09-01 | 2009-09-01 | 9 | 0d | PM; Developer; Sys Admin | 12h |
| 11 | 3.1.4.1 | Disaster recovery |  | 0.5d | 2009-09-01 | 2009-09-01 |  | 0d |  |  |
| 12 | 3.1.4.2 | Security |  | 0.5d | 2009-09-01 | 2009-09-01 |  | 0d |  |  |
| 13 | 3.1.5 | Reporting requirements |  | 0.5d | 2009-09-01 | 2009-09-01 | 10 | 0d | PM; Sponsor | 8h |
| 14 | 3.1.6 | Hardware requirements |  | 0.5d | 2009-09-02 | 2009-09-02 | 13 | 0d | PM; Developer; Sys Admin | 12h |
| 15 | 3.1.7 | Software requirements |  | 1d | 2009-09-02 | 2009-09-03 | 14 | 0d | PM; Developer; Sys Admin | 24h |
| 16 | 3.2 | **Workflow definition** |  | 5.5d | 2009-09-03 | 2009-09-10 | 6 | 0d |  | 84h |
| 17 | 3.2.1 | **Provisioning management** |  | 0.5d | 2009-09-03 | 2009-09-03 |  | 0d | PM; Developer; Support Manager | 12h |
| 18 | 3.2.1.1 | New customer |  | 0.5d | 2009-09-03 | 2009-09-03 |  | 0d |  |  |
| 19 | 3.2.1.2 | Existing customer |  | 0.5d | 2009-09-03 | 2009-09-03 |  | 0d |  |  |
| 20 | 3.2.2 | Authentication |  | 1d | 2009-09-04 | 2009-09-04 | 17 | 0d | Developer | 8h |
| 21 | 3.2.3 | File management |  | 1d | 2009-09-07 | 2009-09-07 | 20 | 0d | PM; Developer | 16h |
| 22 | 3.2.4 | Email integration |  | 1d | 2009-09-08 | 2009-09-08 | 21 | 0d | PM; Developer | 16h |
| 23 | 3.2.5 | Billing integration |  | 2d | 2009-09-09 | 2009-09-10 | 22 | 0d | PM; Developer | 32h |
| 24 | 3.3 | Project budget definition |  | 2d | 2009-09-11 | 2009-09-14 | 16 | 0d | PM; Sponsor | 32h |
| 25 | 3.4 | Project schedule definition |  | 1d | 2009-09-15 | 2009-09-15 | 24 | 0d | PM | 8h |
| 26 | 3.5 | Project communications plan |  | 0.5d | 2009-09-11 | 2009-09-11 | 16 | 2.5d | PM | 4h |
| 27 | 4 | Project Statement of Work | milestone | 5d | 2009-09-04 | 2009-09-11 | 6FS+1d | 31.5d | PM | 40h |

| ID | WBS | Task | Type | Duration | Start | Finish | Predecessors | Total slack | Resources | Work |
| --- | --- | --- | --- | --- | --- | --- | --- | --- | --- | --- |
| 28 | 5 | **Project execution** |  | 27d | 2009-09-16 | 2009-10-22 | 5 | 0d |  | 568h |
| 29 | 5.1 | Interface design |  | 5d | 2009-09-16 | 2009-09-22 |  | 22d | Developer | 40h |
| 30 | 5.2 | Online help system design |  | 5d | 2009-09-16 | 2009-09-22 |  | 22d | Support Manager; Developer 2 | 80h |
| 31 | 5.3 | **Development Environment Deployment** |  | 2d | 2009-09-16 | 2009-09-17 |  | 0d |  | 24h |
| 32 | 5.3.1 | Hardware |  | 1d | 2009-09-16 | 2009-09-16 |  | 0d | Sys Admin | 8h |
| 33 | 5.3.2 | Software |  | 1d | 2009-09-17 | 2009-09-17 | 32 | 0d | Sys Admin; Developer | 16h |
| 34 | 5.4 | Custom Software Development |  | 14d | 2009-09-18 | 2009-10-07 | 31 | 0d | Developer; Developer 2 | 224h |
| 35 | 5.5 | System Beta and Quality Testing | milestone | 3d | 2009-10-08 | 2009-10-12 | 34 | 0d | Developer; Beta team; PM; Sys Admin | 96h |
| 36 | 5.6 | **Production Environment Deployment** |  | 7d | 2009-10-13 | 2009-10-21 | 35 | 0d |  | 80h |
| 37 | 5.6.1 | Hardware |  | 2d | 2009-10-13 | 2009-10-14 |  | 0d | Sys Admin | 16h |
| 38 | 5.6.2 | Software |  | 2d | 2009-10-15 | 2009-10-16 | 37 | 0d | Developer | 16h |
| 39 | 5.6.3 | Custom Code |  | 3d | 2009-10-19 | 2009-10-21 | 38 | 0d | Developer; Developer 2 | 48h |
| 40 | 5.7 | **Documentation** |  | 8d | 2009-10-13 | 2009-10-22 |  | 0d |  | 24h |
| 41 | 5.7.1 | End user specific |  | 2d | 2009-10-13 | 2009-10-14 | 35 | 6d | Support Manager | 16h |
| 42 | 5.7.2 | Technical / administrative |  | 1d | 2009-10-22 | 2009-10-22 | 36 | 0d | Developer | 8h |
| 43 | 6 | **Project closeout** |  | 2d | 2009-10-23 | 2009-10-26 | 28 | 0d | PM | 16h |
| 44 | 6.1 | Transition to Operations Management |  | 1d | 2009-10-23 | 2009-10-23 |  | 0d |  |  |
| 45 | 6.2 | Transition to Sales and marketing |  | 1d | 2009-10-26 | 2009-10-26 | 44 | 0d |  |  |
